# cms-fwd-as01

Schedule from MS Project, 2003-04-24 to 2006-09-21.
CERN

## Calendars

- Standard: Mon-Fri 08:00-12:00, 13:00-17:00; Sat-Sun off.

## Schedule

| ID | Task | Type | Duration | Start | Finish | Predecessors | Total slack | Free slack | Constraint |
| --- | --- | --- | --- | --- | --- | --- | --- | --- | --- |
| 1 | Order Bakelite |  | 1w | 2003-04-24 | 2003-04-30 |  | 42d |  |  |
| 2 | Submit ISIEC |  | 1w | 2003-04-24 | 2003-04-30 |  | 42d |  |  |
| 3 | Prepare Test Chambers |  | 8w | 2003-05-05 | 2003-06-27 |  | 0d |  | start no earlier than 2003-05-05 |
| 4 | Space Plan at ISR |  | 1w | 2003-04-24 | 2003-04-30 |  | 41d | 22d | start no earlier than 2003-04-24 |
| 5 | Preparation of Space ISR |  | 4w | 2003-05-05 | 2003-05-30 |  | 19d | 0d | start no earlier than 2003-05-05 |
| 6 | Gas System QC1 |  | 5w | 2003-04-28 | 2003-05-30 |  | 19d | 0d | finish no earlier than 2003-05-30 |
| 7 | Gas System QC2 |  | 5w | 2003-04-28 | 2003-05-30 |  | 20d |  | start no earlier than 2003-04-28 |
| 8 | Safety requirements |  | 3w | 2003-05-12 | 2003-05-30 |  | 20d |  | start no earlier than 2003-05-12 |
| 9 | Safety Visit |  | 1d | 2003-06-02 | 2003-06-02 | 4, 5, 6 | 19d |  |  |
| 10 | Final - 2 - Chambers |  | 6w | 2003-06-30 | 2003-08-08 | 1, 2, 3, 4, 5, 6, 7, 8, 9 | 0d |  |  |
| 11 | Mechanics |  | 1w | 2003-04-24 | 2003-04-30 |  | 72d |  |  |
| 12 | FEB - Adapter board |  | 2w | 2003-04-24 | 2003-05-07 |  | 62d | 0d |  |
| 13 | DAQ - RO - Cabling - HV |  | 1w | 2003-05-08 | 2003-05-14 | 12 | 62d |  |  |
| 14 | Testing Final - 2 - chambers |  | 1w | 2003-08-11 | 2003-08-15 | 10, 13, 11, 12 | 0d |  |  |
| 15 | Gaps for EDR Chambers |  | 3w | 2003-04-24 | 2003-05-14 |  | 117d | 15d |  |
| 16 | Mechanics |  | 3w | 2003-04-24 | 2003-05-14 |  | 127d | 0d |  |
| 17 | FEB - Adapter board |  | 3w | 2003-04-24 | 2003-05-14 |  | 127d | 15d |  |
| 18 | DAQ - RO - Cabling - HV |  | 3w | 2003-04-24 | 2003-05-14 |  | 117d | 0d |  |
| 19 | QC1 - EDR Chambers |  | 1w | 2003-05-15 | 2003-05-21 | 18 | 846d | 0d |  |
| 20 | QC2 EDR Chambers |  | 2w | 2003-05-22 | 2003-06-04 | 19 | 846d | 0d |  |
| 21 | Testing EDR - chambers |  | 3w | 2003-06-05 | 2003-06-25 | 15, 16, 17, 20 | 846d |  |  |
| 22 | I Gaps for RE1/2 Production Set 1 |  | 12w | 2003-08-18 | 2003-11-07 | 14 | 0d |  |  |
| 23 | I Mechanics |  | 12w | 2003-08-18 | 2003-11-07 | 14 | 661d | 0d |  |
| 24 | I FEB - Adapter board |  | 12w | 2003-08-18 | 2003-11-07 | 14 | 0d |  |  |
| 25 | I RO - Cabling - HV |  | 12w | 2003-04-24 | 2003-07-16 |  | 72d | 0d |  |
| 26 | I QC1 | milestone | 2w | 2003-11-10 | 2003-11-21 | 25, 22, 23, 24 | 661d | 19d |  |
| 27 | X-MAS HOLIDAYS |  | 3w | 2003-12-19 | 2004-01-08 | 26 | 642d | 0d | start no earlier than 2003-12-19 |
| 28 | I QC2 Testing 40 RE1/2 - chambers QC2 |  | 12w | 2004-01-09 | 2004-04-01 | 22, 23, 24, 27 | 642d | 0d |  |
| 29 | Transport to X5 | milestone | 3d | 2004-04-02 | 2004-04-06 | 28 | 642d |  |  |
| 30 | II Gaps for RE1/2 Production Set 2 |  | 12w | 2003-11-10 | 2004-01-30 | 15FS+10d, 22 | 0d |  |  |
| 31 | II Mechanics |  | 12w | 2003-05-15 | 2003-08-06 | 16 | 127d |  |  |
| 32 | II FEB - Adapter board |  | 12w | 2003-11-10 | 2004-01-30 | 17, 24 | 0d |  |  |
| 33 | II RO - Cabling - HV |  | 12w | 2003-07-17 | 2003-10-08 | 18, 25 | 72d | 0d |  |
| 34 | II QC1 Testing 40 RE1/2 |  | 2w | 2003-10-09 | 2003-10-22 | 33 | 72d |  |  |
| 35 | II QC2 Testing 40 RE1/2 - chambers |  | 12w | 2004-02-02 | 2004-04-23 | 30, 31, 32, 34 | 0d |  |  |
| 36 | Transport to X5 | milestone | 3d | 2004-04-26 | 2004-04-28 | 35 | 0d |  |  |
| 37 | I Gaps for RE1/3 Production Set 1 |  | 12w | 2004-04-29 | 2004-07-21 | 36 | 0d |  |  |
| 38 | I Mechanics |  | 12w | 2004-07-22 | 2004-10-13 | 37 | 0d |  |  |
| 39 | I FEB - Adapter board |  | 12w | 2004-10-14 | 2005-01-05 | 38 | 0d |  |  |
| 40 | I RO - Cabling - HV |  | 12w | 2005-01-06 | 2005-03-30 | 39 | 0d |  |  |
| 41 | I QC1 Testing 40 RE1/3 |  | 2w | 2005-03-31 | 2005-04-13 | 40 | 0d |  |  |
| 42 | I QC2 Testing 40 RE1/3 - chambers |  | 12w | 2005-04-14 | 2005-07-06 | 37, 38, 39, 41 | 0d |  |  |
| 43 | Transport to X5 | milestone | 3d | 2005-07-07 | 2005-07-11 | 42 | 0d |  |  |
| 44 | II Gaps for RE1/2 Production Set 2 |  | 12w | 2005-07-12 | 2005-10-03 | 43 | 0d |  |  |
| 45 | II Mechanics |  | 12w | 2005-10-04 | 2005-12-26 | 44 | 0d |  |  |
| 46 | II FEB - Adapter board |  | 12w | 2005-12-27 | 2006-03-20 | 45 | 0d |  |  |
| 47 | II RO - Cabling - HV |  | 12w | 2006-03-21 | 2006-06-12 | 46 | 0d |  |  |
| 48 | II QC1 Testing 40 RE1/3 |  | 2w | 2006-06-13 | 2006-06-26 | 47 | 0d |  |  |
| 49 | II QC2 Testing 40 RE1/3 - chambers |  | 12w | 2006-06-27 | 2006-09-18 | 44, 45, 46, 48 | 0d |  |  |
| 50 | Transport to X5 | milestone | 3d | 2006-09-19 | 2006-09-21 | 49 | 0d |  |  |

Notes:
- 3: Can be completed under follwoing assumptions: / 1. Gaps obtaines from Korea or GT / 2. Mechanics Obtained from China
- 6: Bubblers, Patch panels, Connectors, Flowmeters / 1. For QC1 / 2. For QC2
- 8: ISIEC etc preparation
- 9: Schaefer / Ian could organize this
